# VDC Cernknica G+O+I

How a schedule from MS Project changed from version to version. A marks actual dates.

## Version 1 (saved 2007-02-12, file VDC Cerknica.mpp)

| ID | WBS | Task | Duration | Start | Finish | Predecessors | Total float |
| --- | --- | --- | --- | --- | --- | --- | --- |
| 1 | 1 | **Pripravljalna dela** | 7d | 2004-09-21 | 2004-09-29 |  | 0d |
| 2 |  | Zakoličba, postavitev gradbišča | 7d | 2004-09-21 | 2004-09-29 |  | 0d |
| 3 | 2 | **GRADBENA DELA** | 185.15d | 2004-09-25 | 2005-05-18 |  | 0d |
| 4 | 2.1 | **Zemeljska dela** | 35.84d | 2004-09-25 | 2004-11-09 |  | 0d |
| 5 |  | Odriv humusa | 2.43d | 2004-09-25 | 2004-09-28 | 2SS+4d | 0d |
| 6 |  | Široki izkop | 7.24d | 2004-09-28 | 2004-10-07 | 5 | 0d |
| 7 |  | Zasip temeljev | 6.53d | 2004-10-30 | 2004-11-09 | 11SS+3d | 202.3d |
| 8 | 2.2 | **Armiranobetonska dela** | 78.77d | 2004-09-30 | 2005-01-12 |  | 0d |
| 9 |  | Podložni betoni | 4.31d | 2004-09-30 | 2004-10-06 | 6SS+2d | 0d |
| 10 |  | Pasovni temelji | 11.82d | 2004-10-07 | 2004-10-21 | 28SS+3d | 0d |
| 11 |  | Nastavki temeljev | 9.86d | 2004-10-27 | 2004-11-09 | 29FS+2d | 0d |
| 12 |  | AB kinete | 7.27d | 2004-11-02 | 2004-11-10 | 30SS+1d | 0d |
| 13 |  | Temeljna plošča | 4.85d | 2004-11-15 | 2004-11-19 | 31 | 0d |
| 14 |  | Stene pritličje | 8.24d | 2004-11-26 | 2004-12-06 | 32SS+3d | 0d |
| 15 |  | Dvigalni jašek | 8d | 2004-12-08 | 2004-12-18 | 33SS+4d | 169.21d |
| 16 |  | Plošča I. Nadstropje | 4.01d | 2004-12-10 | 2004-12-15 | 34 | 0d |
| 17 |  | Stene,stebri I. Nadstropje | 4.02d | 2004-12-16 | 2004-12-21 | 35SS+1d | 116.94d |
| 18 |  | Plošča II. Nadstropje | 4.63d | 2005-01-06 | 2005-01-12 | 36 | 116.94d |
| 19 |  | Stopnišče | 0.45d | 2005-01-03 | 2005-01-04 | 37FS+6d | 161.79d |
| 20 | 2.3 | **Zidarska dela** | 104.24d | 2004-11-13 | 2005-03-26 |  | 33.43d |
| 21 |  | Hidroizolacija tlaka | 2.87d | 2004-12-23 | 2005-01-03 | 16FS+7d | 0d |
| 22 |  | Zidanje sten | 20.65d | 2005-01-03 | 2005-01-28 | 21 | 0d |
| 23 |  | Estrihi | 10.11d | 2005-03-15 | 2005-03-26 | 24FS+2d, 66SS+4d | 0d |
| 24 |  | Ometi sten | 12.17d | 2005-02-10 | 2005-02-24 | 22FS+10d | 0d |
| 25 |  | Hišna kanalizacija | 3.47d | 2004-11-13 | 2004-11-17 | 13FF-2d | 153.76d |
| 26 |  | Vzidave, zidarske obdelave | 25.65d | 2005-01-28 | 2005-03-01 | 22 | 74.63d |
| 27 | 2.4 | **Tesarska dela** | 156.38d | 2004-10-04 | 2005-04-19 |  | 0d |
| 28 |  | Opaž-Pasovni temelji | 10.95d | 2004-10-04 | 2004-10-16 | 9FS-2d | 0d |
| 29 |  | Opaž-Nastavki temeljev | 11.56d | 2004-10-11 | 2004-10-25 | 10SS+3d | 0d |
| 30 |  | Opaž-AB kinete | 7d | 2004-10-30 | 2004-11-09 | 11SS+3d | 0d |
| 31 |  | Opaž-Temeljna plošča | 3d | 2004-11-10 | 2004-11-15 | 12 | 0d |
| 32 |  | Opaž-Stene pritličje | 9.51d | 2004-11-23 | 2004-12-03 | 13FS+2d | 0d |
| 33 |  | Opaž-Dvigalni jašek | 10d | 2004-12-03 | 2004-12-16 | 32 | 169.21d |
| 34 |  | Opaž-Plošča I. Nadstropje | 6.95d | 2004-12-02 | 2004-12-10 | 14SS+5d | 0d |
| 35 |  | Opaž-Stene,stene stebri I. Nadstropje | 4.04d | 2004-12-15 | 2004-12-20 | 16 | 116.94d |
| 36 |  | Opaž-Plošča II. Nadstropje | 7.17d | 2004-12-21 | 2005-01-06 | 17 | 116.94d |
| 37 |  | Opaž-Stopnišče | 3.52d | 2004-12-15 | 2004-12-20 | 16 | 161.79d |
| 38 |  | Fasadni odri | 28.06d | 2005-03-16 | 2005-04-19 | 68SS-5d | 74.01d |
| 39 | 2.5 | **Pomožni objekt** | 19.58d | 2005-03-26 | 2005-04-19 |  | 74.38d |
| 40 |  | Groba gradnja | 12.58d | 2005-03-26 | 2005-04-11 | 20 | 74.38d |
| 41 |  | Finalizacija-agrgat, smeti | 7d | 2005-04-11 | 2005-04-19 | 40 | 74.38d |
| 42 | 2.6 | **Kanalizacija** | 115.08d | 2004-11-11 | 2005-04-07 |  | 84.77d |
| 43 |  | Priključni kanal | 4.32d | 2005-03-18 | 2005-03-23 | 20FS-7d | 53d |
| 44 |  | Notranja kanalizacija | 5.13d | 2004-11-11 | 2004-11-17 | 13FF-2d | 194.72d |
| 45 |  | Zunanja kanalizacija-fekalna | 4.9d | 2005-03-23 | 2005-03-29 | 43 | 53d |
| 46 |  | Zunanja kanalizacija-meteorna | 6.97d | 2005-03-29 | 2005-04-07 | 45 | 53d |
| 47 | 2.7 | **Zunanja ureditev** | 27.77d | 2005-04-12 | 2005-05-18 |  | 53d |
| 48 |  | Zemeljska dela, izkop, planum | 4.91d | 2005-04-12 | 2005-04-18 | 46FS+4d | 53d |
| 49 |  | Robni elementi, kanalete, jaški | 10.23d | 2005-04-18 | 2005-05-03 | 48 | 53d |
| 50 |  | Asfalt | 4d | 2005-05-12 | 2005-05-17 | 52 | 53d |
| 51 |  | Oprema cest | 1.63d | 2005-05-17 | 2005-05-18 | 50 | 53d |
| 52 |  | Hortikulturna ureditev | 7d | 2005-05-03 | 2005-05-12 | 49 | 53d |
| 54 | 3 | **OBRTNIŠKA DELA** | 132.99d | 2005-01-20 | 2005-07-04 |  | 14.95d |
| 55 |  | Lesene konstrikcije | 7d | 2005-01-20 | 2005-01-28 | 18FS+7d | 116.94d |
| 56 |  | Krovska dela | 10d | 2005-01-28 | 2005-02-10 | 55 | 116.94d |
| 57 |  | Kleparska dela | 10d | 2005-02-15 | 2005-02-28 | 58 | 116.94d |
| 58 |  | Strešna okna, lopute | 4d | 2005-02-10 | 2005-02-15 | 56 | 116.94d |
| 59 | 3.5 | **Ključavničarska dela** | 32d | 2005-03-26 | 2005-05-07 |  | 61.95d |
| 60 |  | Ograje, ročaji | 7d | 2005-04-01 | 2005-04-11 | 23FS+5d | 81.95d |
| 61 |  | Drsna kovinska vrata | 5d | 2005-03-26 | 2005-04-01 | 23 | 83.95d |
| 62 |  | Dvižna vrata | 5d | 2005-04-01 | 2005-04-07 | 61 | 83.95d |
| 63 |  | WC kabine | 5d | 2005-05-02 | 2005-05-07 | 80FS+2d | 61.95d |
| 64 | 3.6 | **Okna, Vrata** | 57.11d | 2005-03-01 | 2005-05-11 |  | 0d |
| 65 |  | Obodne zasteklitve | 8d | 2005-03-01 | 2005-03-10 | 24FS+3d | 0d |
| 66 |  | Okna | 10d | 2005-03-10 | 2005-03-22 | 65 | 0d |
| 67 |  | Obrobe, alu police, senčila | 6d | 2005-03-31 | 2005-04-07 | 68 | 84.07d |
| 68 |  | Fasadni elementi | 8d | 2005-03-22 | 2005-03-31 | 66 | 84.07d |
| 69 |  | Notranje steklene stene | 5d | 2005-04-26 | 2005-05-05 | 82 | 58.95d |
| 70 |  | Alu vrata | 5d | 2005-05-05 | 2005-05-11 | 69 | 58.95d |
| 71 |  | Mizarska dela | 10d | 2005-05-28 | 2005-06-09 | 90 | 34.95d |

| ID | WBS | Task | Duration | Start | Finish | Predecessors | Total float |
| --- | --- | --- | --- | --- | --- | --- | --- |
| 72 | 3.8 | **Fasaderska dela** | 22d | 2005-03-24 | 2005-04-20 |  | 74.01d |
| 73 |  | Tanakoslojna fasada | 14d | 2005-03-24 | 2005-04-11 | 66, 38FF-7d | 82.01d |
| 74 |  | Leseni del fasade | 12d | 2005-03-30 | 2005-04-14 | 38FF-4d | 74.01d |
| 75 |  | Zaključki | 5d | 2005-04-14 | 2005-04-20 | 74 | 74.01d |
| 76 | 3.9 | **Kamnoseška dela** | 8d | 2005-04-26 | 2005-05-09 |  | 60.95d |
| 77 |  | Tlaki | 5d | 2005-04-26 | 2005-05-05 | 80 | 60.95d |
| 78 |  | Portali | 3d | 2005-05-05 | 2005-05-09 | 77 | 60.95d |
| 79 |  | Okenske police | 3d | 2005-05-05 | 2005-05-09 | 77 | 60.95d |
| 80 | 3.10 | **Keramičarska dela** | 20d | 2005-04-01 | 2005-04-26 |  | 58.95d |
| 81 |  | Stenska obloga | 10d | 2005-04-01 | 2005-04-14 | 23FS+5d | 58.95d |
| 82 |  | Tlaki2 | 10d | 2005-04-14 | 2005-04-26 | 81 | 58.95d |
| 83 | 3.11 | **Mavčarska dela** | 44d | 2005-04-19 | 2005-06-14 |  | 0d |
| 84 |  | Predelne stene | 10d | 2005-04-19 | 2005-05-04 | 89FF | 24.95d |
| 85 |  | Spuščeni stropovi | 14d | 2005-05-28 | 2005-06-14 | 90 | 0d |
| 86 |  | Montaža dvigala | 14d | 2005-04-07 | 2005-04-25 | 23FS+10d | 69.95d |
| 87 |  | Razna dela | 3d | 2005-05-28 | 2005-06-01 | 90 | 41.95d |
| 88 | 3.14 | **Slikopleskarska dela** | 67d | 2005-04-01 | 2005-06-24 |  | 0d |
| 89 |  | Kitanje sten in stropov | 24d | 2005-04-01 | 2005-05-04 | 23FS+5d, 24FS+20d | 0d |
| 90 |  | Slikanje ometanih sten,stropov | 20d | 2005-05-04 | 2005-05-28 | 89 | 0d |
| 91 |  | Slikanje knauf sten | 12d | 2005-05-13 | 2005-05-28 | 90FF | 44.95d |
| 92 |  | Slikopleskarska razna dela, popravila | 9d | 2005-06-14 | 2005-06-24 | 85 | 21.95d |
| 93 |  | Tlakarska dela | 15d | 2005-06-07 | 2005-06-24 | 85SS+8d | 0d |
| 94 | 3.16 | **STROJNE INSTALACIJE** | 100d | 2005-02-11 | 2005-06-15 |  | 24.95d |
| 95 |  | Groba montaža | 70d | 2005-02-11 | 2005-05-10 | 84FF+5d | 24.95d |
| 96 |  | Fina montaža | 20d | 2005-05-23 | 2005-06-15 | 95FS+10d | 29.95d |
| 97 | 3.17 | **ELEKTROINSTALACIJE** | 105d | 2005-02-11 | 2005-06-21 |  | 24.95d |
| 98 |  | Groba montaža2 | 80d | 2005-02-11 | 2005-05-23 | 95FF+10d | 24.95d |
| 99 |  | Fina montaža 2 | 20d | 2005-05-28 | 2005-06-21 | 98FS+5d | 24.95d |
| 101 |  | Finalizacija del | 7d | 2005-06-24 | 2005-07-04 | 93 | 0d |
| 102 |  | Finalno čiščenje | 3.95d | 2005-07-04 | 2005-07-08 | 101 | 0d |
| 103 |  | Tehnični pregled | 1d | 2005-07-08 | 2005-07-09 | 102 | 0d |
| 104 |  | Oprava napak pred predajo objekta | 8d | 2005-07-09 | 2005-07-20 | 103 | 0d |
| 105 |  | Primopredaja objekta | 2d | 2005-07-20 | 2005-07-22 | 104 | 0d |

## Version 2 (data date 2007-02-09, saved 2007-03-06, file Plan - VDC Cerknica1.mpp)

Last finish 2005-07-22 → 2005-08-08 (+17d). Complete tasks 0 → 92.

Added:

| ID | Task | Duration | Start | Finish | Predecessors | Constraint | Resources |
| --- | --- | --- | --- | --- | --- | --- | --- |
| 12 | zastoj - sprememba projektov | 12.68d | 2004-11-09 A | 2004-11-23 A | 11 |  | Delavec [526.3%] |
| 13 | nastavki temeljev - 65 cm | 7.68d | 2004-11-24 A | 2004-12-06 A | 32SS+2d |  | Delavec [1263.2%] |
| 32 | opaž - nastavki temeljev 65 cm | 13.68d | 2004-11-23 A | 2004-12-07 A | 12 |  | Delavec [2210.5%] |
| 105 | grobo čiščenje | 31d | 2005-03-29 A | 2005-06-17 A |  |  | Delavec [421.1%] |
| 110 | stroški gradbišča, njemnia za osnovna sredstva, transport | 227.37d | 2004-09-17 A | 2005-07-01 A |  | start no earlier than 2004-09-17 |  |
| 111 | najem prevoznega sredstva, prevoz delavcev | 170.89d | 2004-10-26 A | 2005-05-31 A |  |  |  |
| 112 | režija | 253.58d | 2004-09-17 A | 2005-08-02 A |  |  |  |
| 113 | stroški zaposlenih, stroški podjetja | 227.37d | 2004-09-17 A | 2005-07-01 A |  |  |  |

Changed:

| ID | Task | Start | Finish | Duration | Complete | Total float | Other |
| --- | --- | --- | --- | --- | --- | --- | --- |
| 1 | **Pripravljalna dela** | 2004-09-21 → 2004-09-17 A (-4d) | 2004-09-29 → 2004-10-19 A (+20d) | 7d → 27.11d | 0% → 100% | 0d → none | baseline finish 2005-07-22 → 2004-09-29 |
| 2 | Zakoličba, postavitev gradbišča | 2004-09-21 → 2004-09-17 A (-4d) | 2004-09-29 → 2004-10-19 A (+20d) | 7d → 16.63d | 0% → 100% | 0d → none | constraint none → start no earlier than 2004-09-17; resources Delavec [50%] → Delavec [578.9%] |
| 3 | **GRADBENA DELA** | 2004-09-25 → 2004-09-23 A (-2d) | 2005-05-18 → 2005-06-09 A (+22d) | 185.15d → 205.89d | 0% → 100% | 0d → none |  |
| 4 | **Zemeljska dela** | 2004-09-25 → 2004-09-23 A (-2d) | 2004-11-09 → 2004-12-11 A (+32d) | 35.84d → 66d | 0% → 100% | 0d → none |  |
| 5 | Odriv humusa | 2004-09-25 → 2004-09-23 A (-2d) | 2004-09-28 → 2004-09-29 A (+1d) | 2.43d → 5.79d | 0% → 100% | 0d → none | constraint none → start no earlier than 2004-09-23; resources Delavec [50%] → none |
| 6 | Široki izkop | 2004-09-28 → 2004-09-27 A (-1d) | 2004-10-07 → 2004-10-06 A (-1d) | 7.24d → 8.84d | 0% → 100% | 0d → none | constraint none → start no earlier than 2004-09-27; resources Delavec [400%] → none |
| 7 | Zasip temeljev | 2004-10-30 → 2004-11-05 A (+6d) | 2004-11-09 → 2004-12-11 A (+32d) | 6.53d → 31.05d | 0% → 100% | 202.3d → none | constraint none → start no earlier than 2004-11-05; resources Delavec [250%] → none |
| 8 | **Armiranobetonska dela** | 2004-09-30 A | 2005-01-12 → 2005-02-16 A (+35d) | 78.77d → 108.68d | 0% → 100% | 0d → none |  |
| 9 | Podložni betoni | 2004-09-30 A | 2004-10-06 → 2004-10-07 A (+1d) | 4.31d → 6.84d | 0% → 100% | 0d → none | constraint none → start no earlier than 2004-09-30; resources Delavec [200%] → Delavec [463.2%] |
| 10 | Pasovni temelji | 2004-10-07 → 2004-10-12 A (+5d) | 2004-10-21 → 2004-10-23 A (+2d) | 11.82d → 7.84d | 0% → 100% | 0d → none | constraint none → start no earlier than 2004-10-12; resources Delavec → Delavec [700%] |
| 11 | Nastavki temeljev | 2004-10-27 → 2004-10-26 A (-1d) | 2004-11-09 → 2004-11-08 A (-1d) | 9.86d → 7.84d | 0% → 100% | 0d → none | constraint none → start no earlier than 2004-10-26; resources Delavec [200%] → Delavec [1389.5%] |
| 14 | AB kinete | 2004-11-02 → 2004-12-08 A (+36d) | 2004-11-10 → 2004-12-13 A (+33d) | 7.27d → 2d | 0% → 100% | 0d → none | constraint none → finish no earlier than 2004-12-14; resources Delavec [250%] → Delavec [210.5%] |
| 15 | Temeljna plošča | 2004-11-15 → 2004-12-08 A (+23d) | 2004-11-19 → 2004-12-13 A (+24d) | 4.85d → 3d | 0% → 100% | 0d → none | constraint none → start no earlier than 2004-12-08; resources Delavec [500%] → Delavec [1473.7%] |
| 16 | Stene pritličje | 2004-11-26 → 2004-12-14 A (+18d) | 2004-12-06 → 2005-01-17 A (+42d) | 8.24d → 8.84d | 0% → 100% | 0d → none | resources Delavec [200%] → Delavec [1473.7%] |
| 17 | Dvigalni jašek | 2004-12-08 → 2004-12-18 A (+10d) | 2004-12-18 → 2005-02-15 A (+59d) | 8d → 2.84d | 0% → 100% | 169.21d → none | resources none → Delavec [684.2%] |
| 18 | Plošča I. Nadstropje | 2004-12-10 → 2004-12-23 A (+13d) | 2004-12-15 → 2005-01-22 A (+38d) | 4.01d → 3.84d | 0% → 100% | 0d → none | resources Delavec [650%] → Delavec [1284.2%] |
| 19 | Stene,stebri I. Nadstropje | 2004-12-16 → 2005-01-17 A (+32d) | 2004-12-21 → 2005-02-16 A (+57d) | 4.02d → 10d | 0% → 100% | 116.94d → none | resources Delavec [450%] → Delavec [1368.4%] |
| 20 | Plošča II. Nadstropje | 2005-01-06 → 2005-01-25 A (+19d) | 2005-01-12 → 2005-02-16 A (+35d) | 4.63d → 7d | 0% → 100% | 116.94d → none | resources Delavec [450%] → Delavec [894.7%] |
| 21 | Stopnišče | 2005-01-03 → 2005-01-12 A (+9d) | 2005-01-04 → 2005-01-16 A (+12d) | 0.45d → 2d | 0% → 100% | 161.79d → none | resources Delavec → Delavec [210.5%] |
| 22 | **Zidarska dela** | 2004-11-13 → 2004-12-08 A (+25d) | 2005-03-26 → 2005-05-19 A (+54d) | 104.24d → 126.21d | 0% → 100% | 33.43d → none |  |
| 23 | Hidroizolacija tlaka | 2004-12-23 → 2004-12-14 A (-9d) | 2005-01-03 → 2005-04-04 A (+91d) | 2.87d → 85.58d | 0% → 100% | 0d → none | resources Delavec [400%] → none |
| 24 | Zidanje sten | 2005-01-03 → 2005-01-20 A (+17d) | 2005-01-28 → 2005-03-15 A (+46d) | 20.65d → 25.53d | 0% → 100% | 0d → none | resources Delavec [350%] → Delavec [675%] |
| 25 | Estrihi | 2005-03-15 → 2005-03-30 A (+15d) | 2005-03-26 → 2005-04-07 A (+12d) | 10.11d → 6d | 0% → 100% | 0d → none | resources Delavec [1350%] → Delavec [315.8%] |
| 26 | Ometi sten | 2005-02-10 → 2005-04-02 A (+51d) | 2005-02-24 → 2005-04-14 A (+49d) | 12.17d → 10.68d | 0% → 100% | 0d → none | resources Delavec [550%] → none |
| 27 | Hišna kanalizacija | 2004-11-13 → 2004-12-08 A (+25d) | 2004-11-17 → 2004-12-11 A (+24d) | 3.47d → 3.84d | 0% → 100% | 153.76d → none | resources Delavec [50%] → Delavec [168.4%] |
| 28 | Vzidave, zidarske obdelave | 2005-01-28 → 2005-01-14 A (-14d) | 2005-03-01 → 2005-05-19 A (+79d) | 25.65d → 40.89d | 0% → 100% | 74.63d → none | constraint none → finish no earlier than 2005-05-19; resources Delavec [150%] → Delavec [1263.2%] |
| 29 | **Tesarska dela** | 2004-10-04 → 2004-10-08 A (+4d) | 2005-04-19 → 2005-05-19 A (+30d) | 156.38d → 175.74d | 0% → 100% | 0d → none |  |
| 30 | Opaž-Pasovni temelji | 2004-10-04 → 2004-10-08 A (+4d) | 2004-10-16 → 2004-10-25 A (+9d) | 10.95d → 12.84d | 0% → 100% | 0d → none | resources tesar [350%] → Delavec [715.8%] |
| 31 | Opaž-Nastavki temeljev | 2004-10-11 → 2004-10-21 A (+10d) | 2004-10-25 → 2004-11-09 A (+15d) | 11.56d → 13.68d | 0% → 100% | 0d → none | resources tesar [750%] → Delavec [1578.9%] |
| 33 | Opaž-AB kinete | 2004-10-30 → 2004-12-02 A (+33d) | 2004-11-09 → 2004-12-10 A (+31d) | 7d → 6d | 0% → 100% | 0d → none | resources none → Delavec [784.2%] |
| 34 | Opaž-Temeljna plošča | 2004-11-10 → 2004-12-06 A (+26d) | 2004-11-15 → 2004-12-14 A (+29d) | 3d → 6.84d | 0% → 100% | 0d → none | resources none → Delavec [1575%] |
| 35 | Opaž-Stene pritličje | 2004-11-23 → 2004-12-11 A (+18d) | 2004-12-03 → 2005-01-18 A (+46d) | 9.51d → 19.53d | 0% → 100% | 0d → none | resources tesar [400%] → Delavec [1263.2%] |
| 36 | Opaž-Dvigalni jašek | 2004-12-03 → 2004-12-18 A (+15d) | 2004-12-16 → 2005-02-15 A (+61d) | 10d → 8.53d | 0% → 100% | 169.21d → none | resources none → Delavec [500%] |
| 37 | Opaž-Plošča I. Nadstropje | 2004-12-02 → 2004-12-16 A (+14d) | 2004-12-10 → 2005-01-29 A (+50d) | 6.95d → 22.53d | 0% → 100% | 0d → none | resources tesar [1050%] → Delavec [1989.5%] |
| 38 | Opaž-Stene,stene stebri I. Nadstropje | 2004-12-15 → 2005-01-13 A (+29d) | 2004-12-20 → 2005-02-17 A (+59d) | 4.04d → 26.37d | 0% → 100% | 116.94d → none | resources tesar [1100%] → Delavec [1473.7%] |
| 39 | Opaž-Plošča II. Nadstropje | 2004-12-21 → 2005-01-24 A (+34d) | 2005-01-06 → 2005-02-28 A (+53d) | 7.17d → 25.53d | 0% → 100% | 116.94d → none | resources tesar [1250%] → Delavec [1663.2%] |
| 40 | Opaž-Stopnišče | 2004-12-15 → 2005-01-03 A (+19d) | 2004-12-20 → 2005-01-15 A (+26d) | 3.52d → 7.84d | 0% → 100% | 161.79d → none | resources tesar → Delavec [189.5%] |
| 41 | Fasadni odri | 2005-03-16 → 2005-01-17 A (-58d) | 2005-04-19 → 2005-05-19 A (+30d) | 28.06d → 23.53d | 0% → 100% | 74.01d → none | resources Delavec [250%] → Delavec [631.6%] |
| 42 | **Pomožni objekt** | 2005-03-26 → 2005-03-18 A (-8d) | 2005-04-19 → 2005-06-09 A (+51d) | 19.58d → 67.05d | 0% → 100% | 74.38d → none |  |
| 43 | Groba gradnja | 2005-03-26 → 2005-03-18 A (-8d) | 2005-04-11 A | 12.58d → 14.68d | 0% → 100% | 74.38d → none | resources Delavec [150%] → Delavec [675%] |
| 44 | Finalizacija-agrgat, smeti | 2005-04-11 → 2005-04-12 A (+1d) | 2005-04-19 → 2005-06-09 A (+51d) | 7d → 46.68d | 0% → 100% | 74.38d → none |  |
| 45 | **Kanalizacija** | 2004-11-11 → 2004-11-30 A (+19d) | 2005-04-07 → 2005-05-06 A (+29d) | 115.08d → 122.37d | 0% → 100% | 84.77d → none |  |
| 46 | Priključni kanal | 2005-03-18 → 2005-03-21 A (+3d) | 2005-03-23 → 2005-03-25 A (+2d) | 4.32d → 5d | 0% → 100% | 53d → none | resources Delavec [200%] → Delavec [105.3%] |
| 47 | Notranja kanalizacija | 2004-11-11 → 2004-11-30 A (+19d) | 2004-11-17 → 2004-12-09 A (+22d) | 5.13d → 5d | 0% → 100% | 194.72d → none | resources Delavec [800%] → Delavec [726.3%] |
| 48 | Zunanja kanalizacija-fekalna | 2005-03-23 → 2005-04-21 A (+29d) | 2005-03-29 → 2005-05-06 A (+38d) | 4.9d → 5.84d | 0% → 100% | 53d → none | resources Delavec [900%] → Delavec [421.1%] |
| 49 | Zunanja kanalizacija-meteorna | 2005-03-29 → 2005-04-15 A (+17d) | 2005-04-07 → 2005-05-06 A (+29d) | 6.97d → 9.68d | 0% → 100% | 53d → none | resources Delavec [1450%] → Delavec [947.4%] |
| 50 | **Zunanja ureditev** | 2005-04-12 A | 2005-05-18 → 2005-06-09 A (+22d) | 27.77d → 46.68d | 0% → 100% | 53d → none |  |
| 51 | Zemeljska dela, izkop, planum | 2005-04-12 → 2005-04-20 A (+8d) | 2005-04-18 → 2005-05-06 A (+18d) | 4.91d → 11.63d | 0% → 100% | 53d → none | resources Delavec [1600%] → none |
| 52 | Robni elementi, kanalete, jaški | 2005-04-18 → 2005-04-12 A (-6d) | 2005-05-03 → 2005-05-27 A (+24d) | 10.23d → 23.53d | 0% → 100% | 53d → none | resources Delavec [550%] → Delavec [1157.9%] |
| 53 | Asfalt | 2005-05-12 → 2005-05-23 A (+11d) | 2005-05-17 → 2005-05-24 A (+7d) | 4d → 2d | 0% → 100% | 53d → none | baseline start 2005-05-12 → 2005-05-11 |
| 54 | Oprema cest | 2005-05-17 → 2005-05-24 A (+7d) | 2005-05-18 → 2005-05-25 A (+7d) | 1.63d → 0d | 0% → 100% | 53d → none | resources none → Delavec [50%] |
| 55 | Hortikulturna ureditev | 2005-05-03 → 2005-05-25 A (+22d) | 2005-05-12 → 2005-06-09 A (+28d) | 7d → 12.68d | 0% → 100% | 53d → none | resources none → Delavec [526.3%]; baseline finish 2005-05-12 → 2005-05-11 |
| 57 | **OBRTNIŠKA DELA** | 2005-01-20 → 2005-03-07 A (+46d) | 2005-07-04 → 2005-07-11 A (+7d) | 132.99d → 101.42d | 0% → 100% | 14.95d → none | baseline finish 2005-06-24 → 2005-07-04 |
| 58 | Lesene konstrikcije | 2005-01-20 → 2005-03-11 A (+50d) | 2005-01-28 → 2005-04-21 A (+83d) | 7d → 35.05d | 0% → 100% | 116.94d → none |  |
| 59 | Krovska dela | 2005-01-28 → 2005-03-23 A (+54d) | 2005-02-10 → 2005-04-22 A (+71d) | 10d → 26.37d | 0% → 100% | 116.94d → none |  |
| 60 | Kleparska dela | 2005-02-15 → 2005-04-12 A (+56d) | 2005-02-28 → 2005-04-26 A (+57d) | 10d → 12.68d | 0% → 100% | 116.94d → none |  |
| 61 | Strešna okna, lopute | 2005-02-10 → 2005-03-30 A (+48d) | 2005-02-15 → 2005-04-02 A (+46d) | 4d → 3.84d | 0% → 100% | 116.94d → none |  |
| 62 | **Ključavničarska dela** | 2005-03-26 → 2005-05-05 A (+40d) | 2005-05-07 → 2005-06-04 A (+28d) | 32d → 26.21d | 0% → 100% | 61.95d → none |  |
| 63 | Ograje, ročaji | 2005-04-01 → 2005-05-19 A (+48d) | 2005-04-11 → 2005-06-04 A (+54d) | 7d → 14.53d | 0% → 100% | 81.95d → none |  |
| 64 | Drsna kovinska vrata | 2005-03-26 → 2005-05-05 A (+40d) | 2005-04-01 → 2005-05-27 A (+56d) | 5d → 19.53d | 0% → 100% | 83.95d → none |  |
| 65 | Dvižna vrata | 2005-04-01 → 2005-05-28 A (+57d) | 2005-04-07 → 2005-06-03 A (+57d) | 5d → 5.84d | 0% → 100% | 83.95d → none |  |
| 66 | WC kabine | 2005-05-02 → 2005-05-24 A (+22d) | 2005-05-07 → 2005-05-30 A (+23d) | 5d → 5.84d | 0% → 100% | 61.95d → none |  |
| 67 | **Okna, Vrata** | 2005-03-01 → 2005-03-08 A (+7d) | 2005-05-11 → 2005-05-23 A (+12d) | 57.11d → 61.21d | 0% → 100% | 0d → none |  |
| 68 | Obodne zasteklitve | 2005-03-01 → 2005-03-08 A (+7d) | 2005-03-10 → 2005-04-09 A (+30d) | 8d → 28.21d | 0% → 100% | 0d → none |  |
| 69 | Okna | 2005-03-10 A | 2005-03-22 → 2005-04-12 A (+21d) | 10d → 28.21d | 0% → 100% | 0d → none |  |
| 70 | Obrobe, alu police, senčila | 2005-03-31 A | 2005-04-07 → 2005-05-23 A (+46d) | 6d → 41.68d | 0% → 100% | 84.07d → none |  |
| 71 | Fasadni elementi | 2005-03-22 → 2005-04-09 A (+18d) | 2005-03-31 → 2005-04-19 A (+19d) | 8d → 8.68d | 0% → 100% | 84.07d → none |  |
| 72 | Notranje steklene stene | 2005-04-26 → 2005-05-04 A (+8d) | 2005-05-05 → 2005-05-10 A (+5d) | 5d → 5.84d | 0% → 100% | 58.95d → none |  |
| 73 | Alu vrata | 2005-05-05 → 2005-04-14 A (-21d) | 2005-05-11 → 2005-04-14 A (-27d) | 5d → 1d | 0% → 100% | 58.95d → none |  |
| 74 | Mizarska dela | 2005-05-28 → 2005-05-21 A (-7d) | 2005-06-09 → 2005-05-28 A (-12d) | 10d → 6.68d | 0% → 100% | 34.95d → none |  |

| ID | Task | Start | Finish | Duration | Complete | Total float | Other |
| --- | --- | --- | --- | --- | --- | --- | --- |
| 75 | **Fasaderska dela** | 2005-03-24 → 2005-03-23 A (-1d) | 2005-04-20 → 2005-05-27 A (+37d) | 22d → 52.53d | 0% → 100% | 74.01d → none |  |
| 76 | Tanakoslojna fasada | 2005-03-24 → 2005-03-23 A (-1d) | 2005-04-11 → 2005-05-07 A (+26d) | 14d → 35.84d | 0% → 100% | 82.01d → none |  |
| 77 | Leseni del fasade | 2005-03-30 → 2005-04-12 A (+13d) | 2005-04-14 → 2005-05-21 A (+37d) | 12d → 31d | 0% → 100% | 74.01d → none |  |
| 78 | Zaključki | 2005-04-14 → 2005-05-23 A (+39d) | 2005-04-20 → 2005-05-27 A (+37d) |  | 0% → 100% | 74.01d → none |  |
| 79 | **Kamnoseška dela** | 2005-04-26 → 2005-04-22 A (-4d) | 2005-05-09 → 2005-05-17 A (+8d) | 8d → 18.32d | 0% → 100% | 60.95d → none |  |
| 80 | Tlaki | 2005-04-26 → 2005-05-09 A (+13d) | 2005-05-05 → 2005-05-16 A (+11d) | 5d → 6.84d | 0% → 100% | 60.95d → none |  |
| 81 | Portali | 2005-05-05 → 2005-05-09 A (+4d) | 2005-05-09 → 2005-05-17 A (+8d) | 3d → 7.84d | 0% → 100% | 60.95d → none |  |
| 82 | Okenske police | 2005-05-05 → 2005-04-22 A (-13d) | 2005-05-09 → 2005-04-23 A (-16d) | 3d → 1.84d | 0% → 100% | 60.95d → none |  |
| 83 | **Keramičarska dela** | 2005-04-01 → 2005-04-11 A (+10d) | 2005-04-26 → 2005-05-20 A (+24d) | 20d → 31.16d | 0% → 100% | 58.95d → none |  |
| 84 | Stenska obloga | 2005-04-01 → 2005-04-14 A (+13d) | 2005-04-14 → 2005-05-17 A (+33d) | 10d → 25.16d | 0% → 100% | 58.95d → none |  |
| 85 | Tlaki2 | 2005-04-14 → 2005-04-11 A (-3d) | 2005-04-26 → 2005-05-20 A (+24d) | 10d → 31.16d | 0% → 100% | 58.95d → none |  |
| 86 | **Mavčarska dela** | 2005-04-19 → 2005-04-12 A (-7d) | 2005-06-14 → 2005-05-13 A (-32d) | 44d → 24.32d | 0% → 100% | 0d → none |  |
| 87 | Predelne stene | 2005-04-19 → 2005-04-12 A (-7d) | 2005-05-04 → 2005-05-13 A (+9d) | 10d → 24.32d | 0% → 100% | 24.95d → none |  |
| 88 | Spuščeni stropovi | 2005-05-28 → 2005-04-15 A (-43d) | 2005-06-14 → 2005-05-13 A (-32d) | 14d → 21.32d | 0% → 100% | 0d → none |  |
| 89 | Montaža dvigala | 2005-04-07 → 2005-04-13 A (+6d) | 2005-04-25 → 2005-05-21 A (+26d) | 14d → 30d | 0% → 100% | 69.95d → none |  |
| 90 | Razna dela | 2005-05-28 → 2005-05-18 A (-10d) | 2005-06-01 → 2005-05-21 A (-11d) | 3d → 3.84d | 0% → 100% | 41.95d → none |  |
| 91 | **Slikopleskarska dela** | 2005-04-01 → 2005-04-19 A (+18d) | 2005-06-24 → 2005-06-09 A (-15d) | 67d → 40.84d | 0% → 100% | 0d → none |  |
| 92 | Kitanje sten in stropov | 2005-04-01 → 2005-04-19 A (+18d) | 2005-05-04 → 2005-05-17 A (+13d) | 24d → 21.32d | 0% → 100% | 0d → none |  |
| 93 | Slikanje ometanih sten,stropov | 2005-05-04 → 2005-05-05 A (+1d) | 2005-05-28 → 2005-05-27 A (-1d) | 20d → 19.53d | 0% → 100% | 0d → none |  |
| 94 | Slikanje knauf sten | 2005-05-13 → 2005-05-14 A (+1d) | 2005-05-28 → 2005-05-27 A (-1d) | 12d → 11.68d | 0% → 100% | 44.95d → none |  |
| 95 | Slikopleskarska razna dela, popravila | 2005-06-14 → 2005-05-27 A (-18d) | 2005-06-24 → 2005-06-09 A (-15d) | 9d → 11.68d | 0% → 100% | 21.95d → none |  |
| 96 | Tlakarska dela | 2005-06-07 → 2005-05-19 A (-19d) | 2005-06-24 → 2005-06-03 A (-21d) | 15d → 13.68d | 0% → 100% | 0d → none |  |
| 97 | **STROJNE INSTALACIJE** | 2005-02-11 → 2005-03-08 A (+25d) | 2005-06-15 A | 100d → 80.74d | 0% → 100% | 24.95d → none |  |
| 98 | Groba montaža | 2005-02-11 → 2005-03-08 A (+25d) | 2005-05-10 → 2005-06-02 A (+23d) | 70d → 70.05d | 0% → 100% | 24.95d → none |  |
| 99 | Fina montaža | 2005-05-23 A | 2005-06-15 A | 20d → 20.53d | 0% → 100% | 29.95d → none |  |
| 100 | **ELEKTROINSTALACIJE** | 2005-02-11 → 2005-03-07 A (+24d) | 2005-06-21 → 2005-06-27 A (+6d) | 105d → 90.58d | 0% → 100% | 24.95d → none |  |
| 101 | Groba montaža2 | 2005-02-11 → 2005-03-07 A (+24d) | 2005-05-23 → 2005-06-15 A (+23d) | 80d → 81.74d | 0% → 100% | 24.95d → none |  |
| 102 | Fina montaža 2 | 2005-05-28 → 2005-06-09 A (+12d) | 2005-06-21 → 2005-06-27 A (+6d) | 20d → 14.68d | 0% → 100% | 24.95d → none |  |
| 104 | Finalizacija del | 2005-06-24 → 2005-06-30 A (+6d) | 2005-07-04 → 2005-07-11 A (+7d) | 7d → 8.84d | 0% → 100% | 0d → none |  |
| 106 | Finalno čiščenje | 2005-07-04 → 2005-07-12 A (+8d) | 2005-07-08 → 2005-07-16 A (+8d) | 3.95d → 4.84d | 0% → 100% | 0d → none | resources Delavec [900%] → none |
| 107 | Tehnični pregled | 2005-07-08 → 2005-07-22 A (+14d) | 2005-07-09 → 2005-07-22 A (+13d) |  | 0% → 100% | 0d → none |  |
| 108 | Oprava napak pred predajo objekta | 2005-07-09 → 2005-07-23 A (+14d) | 2005-07-20 → 2005-08-06 A (+17d) | 8d → 12.53d | 0% → 100% | 0d → none |  |
| 109 | Primopredaja objekta | 2005-07-20 → 2005-08-08 A (+19d) | 2005-07-22 → 2005-08-08 A (+17d) | 2d → 1d | 0% → 100% | 0d → none |  |
